# Построение системы управления бизнес-процессами

Schedule from MS Project, 2017-12-21 to 2018-05-31.

## Calendars

- Стандартный: Mon-Fri 09:00-13:00, 14:00-18:00; Sat-Sun off.

## Resources

| Resource |
| --- |
| Эксперт-консультант |
| Руководитель проекта |
| Заказчик |
| Функциональный эксперт |
| Бизнес-аналитик |
| Консультант по ИС |
| Бизнес-тренер |

## Schedule

| ID | WBS | Task | Type | Duration | Start | Finish | Predecessors | Total slack | Resources | Work | Text1 |
| --- | --- | --- | --- | --- | --- | --- | --- | --- | --- | --- | --- |
| 1 | 1 | **Подготовка проекта** |  | 8.75d | 2017-12-21 09:00 | 2018-01-02 16:00 |  | 0d |  | 30.5h |  |
| 2 | 1.1 | **Определение целей и результатов проекта** |  | 2.5d | 2017-12-21 09:00 | 2017-12-25 13:00 |  | 0d |  | 8h |  |
| 3 | 1.1.1 | Вводная консультация с инициаторами проекта со стороны Заказчика |  | 0.5d | 2017-12-21 09:00 | 2017-12-21 13:00 |  | 0d | Эксперт-консультант [25%] | 2h | Видеозапись консультации |
| 4 | 1.1.2 | Подготовка протокола с описанием целей, задач и результатов |  | 0.5d | 2017-12-21 14:00 | 2017-12-21 18:00 | 3 | 0d | Эксперт-консультант | 1h |  |
| 5 | 1.1.3 | Согласование протокола |  | 0.5d | 2017-12-22 09:00 | 2017-12-22 13:00 | 4 | 0d | Руководитель проекта | 2h |  |
| 6 | 1.1.4 | Внесение корректировок в протокол |  | 0.5d | 2017-12-22 14:00 | 2017-12-22 18:00 | 5 | 0d | Эксперт-консультант | 1h |  |
| 7 | 1.1.5 | Утверждение протокола |  | 0.5d | 2017-12-25 09:00 | 2017-12-25 13:00 | 6 | 0d | Заказчик | 2h |  |
| 8 | 1.1.6 | Цели и результаты проекта утверждены | milestone | 0d | 2017-12-25 13:00 | 2017-12-25 13:00 | 7 | 0d |  |  | Протокол "Цели, задачи и результаты проекта" |
| 9 | 1.2 | **Формирование команды проекта** |  | 1.75d | 2017-12-25 14:00 | 2017-12-27 11:00 |  | 0d |  | 5.5h |  |
| 10 | 1.2.1 | Консультация по формированию команды проекта и назначению проектных ролей |  | 0.5d | 2017-12-25 14:00 | 2017-12-25 18:00 | 8 | 0d | Эксперт-консультант | 1h | Видеозапись консультации |
| 11 | 1.2.2 | Составление списка участников проекта |  | 0.5d | 2017-12-26 09:00 | 2017-12-26 13:00 | 10 | 0d | Руководитель проекта | 2h |  |
| 12 | 1.2.3 | Консультация по корректировке списка участников проекта |  | 0.25d | 2017-12-26 14:00 | 2017-12-26 16:00 | 11 | 0d | Эксперт-консультант | 0.5h |  |
| 13 | 1.2.4 | Утверждение списка участников проекта |  | 0.5d | 2017-12-26 16:00 | 2017-12-27 11:00 | 12 | 0d | Заказчик | 2h |  |
| 14 | 1.2.5 | Команда проекта сформирована | milestone | 0d | 2017-12-27 11:00 | 2017-12-27 11:00 | 13 | 0d |  |  | Документ "Список участников проекта" |
| 15 | 1.3 | **Формирование план-графика работ** |  | 3d | 2017-12-27 11:00 | 2018-01-01 11:00 |  | 0d |  | 10h |  |
| 16 | 1.3.1 | Адаптация типового план-графика в соответствии с целями проекта |  | 0.25d | 2017-12-27 11:00 | 2017-12-27 13:00 | 14 | 0d | Эксперт-консультант | 2h |  |
| 17 | 1.3.2 | Консультационная сессия: презентация и защита план-графика |  | 0.25d | 2017-12-27 14:00 | 2017-12-27 16:00 | 16 | 0d | Эксперт-консультант | 2h | Видеозапись консультации |
| 18 | 1.3.3 | Согласование план-графика |  | 1d | 2017-12-27 16:00 | 2017-12-28 16:00 | 17 | 0d | Руководитель проекта | 3h |  |
| 19 | 1.3.4 | Внесение корректировок в план-график |  | 1d | 2017-12-28 16:00 | 2017-12-29 16:00 | 18 | 0d | Эксперт-консультант | 1h |  |
| 20 | 1.3.5 | Утверждение план-графика |  | 0.5d | 2017-12-29 16:00 | 2018-01-01 11:00 | 19 | 0d | Заказчик | 2h |  |
| 21 | 1.3.6 | План-график сформирован | milestone | 0d | 2018-01-01 11:00 | 2018-01-01 11:00 | 20 | 0d |  |  | Документ "План-график проекта" |
| 22 | 1.4 | **Формирование устава проекта** |  | 1.5d | 2018-01-01 11:00 | 2018-01-02 16:00 |  | 0d |  | 7h |  |
| 23 | 1.4.1 | Адаптация типового устава в соответствии со спецификой компании |  | 0.5d | 2018-01-01 11:00 | 2018-01-01 16:00 | 21 | 0d | Эксперт-консультант | 2h |  |
| 24 | 1.4.2 | Консультационная сессия: презентация и защита устава проекта |  | 0.25d | 2018-01-01 16:00 | 2018-01-01 18:00 | 23 | 0d | Эксперт-консультант | 1h | Видеозапись консультации |
| 25 | 1.4.3 | Согласование устава |  | 0.25d | 2018-01-02 09:00 | 2018-01-02 11:00 | 24 | 0d | Руководитель проекта | 2h |  |
| 26 | 1.4.4 | Внесение корректировок в устав |  | 0.25d | 2018-01-02 11:00 | 2018-01-02 13:00 | 25 | 0d | Эксперт-консультант | 1h |  |
| 27 | 1.4.5 | Утверждение устава |  | 0.25d | 2018-01-02 14:00 | 2018-01-02 16:00 | 26 | 0d | Заказчик | 1h |  |
| 28 | 1.4.6 | Устав сформирован | milestone | 0d | 2018-01-02 16:00 | 2018-01-02 16:00 | 27 | 0d |  |  | Документ "Устав проекта" |
| 29 | 1.5 | Подготовка проекта выполнена | milestone | 0d | 2018-01-02 16:00 | 2018-01-02 16:00 | 28 | 0d |  |  |  |

| ID | WBS | Task | Type | Duration | Start | Finish | Predecessors | Total slack | Resources | Work | Text1 |
| --- | --- | --- | --- | --- | --- | --- | --- | --- | --- | --- | --- |
| 30 | 2 | **Обследование компании** |  | 4.5d | 2018-01-02 16:00 | 2018-01-09 11:00 |  | 0d |  | 26h |  |
| 31 | 2.1 | **Анкетирование** |  | 1d | 2018-01-02 16:00 | 2018-01-03 16:00 |  | 0d |  | 5h |  |
| 32 | 2.1.1 | Анкетирование - "Определение уровня организационной зрелости" |  | 0.25d | 2018-01-02 16:00 | 2018-01-02 18:00 | 29 | 0d | Эксперт-консультант | 1h | Анкеты "Определение уровня организационной зрелости" |
| 33 | 2.1.2 | Анкетирование - "Функциональная диагностика бизнес-процессов" |  | 0.25d | 2018-01-03 09:00 | 2018-01-03 11:00 | 32 | 0d | Эксперт-консультант | 1h | Анекты "Функциональная диагностика бизнес-процессов" |
| 34 | 2.1.3 | Обработка результатов анкетирования |  | 0.5d | 2018-01-03 11:00 | 2018-01-03 16:00 | 33 | 0d | Эксперт-консультант | 3h |  |
| 35 | 2.1.4 | Анкетирование выполнено | milestone | 0d | 2018-01-03 16:00 | 2018-01-03 16:00 | 34 | 0d |  |  |  |
| 36 | 2.2 | **Изучение документации** |  | 1d | 2018-01-03 16:00 | 2018-01-04 16:00 |  | 0d |  | 7h |  |
| 37 | 2.2.1 | Изучение внутренних нормативных документов |  | 0.25d | 2018-01-03 16:00 | 2018-01-03 18:00 | 35 | 0d | Эксперт-консультант | 2h |  |
| 38 | 2.2.2 | Изучение текущего ИТ-ландшафта |  | 0.25d | 2018-01-04 09:00 | 2018-01-04 11:00 | 37 | 0d | Эксперт-консультант | 2h |  |
| 39 | 2.2.3 | Обработка результатов исследования |  | 0.5d | 2018-01-04 11:00 | 2018-01-04 16:00 | 38 | 0d | Эксперт-консультант | 3h |  |
| 40 | 2.2.4 | Выполнено исследование документации | milestone | 0d | 2018-01-04 16:00 | 2018-01-04 16:00 | 39 | 0d |  |  |  |
| 41 | 2.3 | **Проведение диагностических интервью** |  | 1.25d | 2018-01-04 16:00 | 2018-01-05 18:00 |  | 0d |  | 7h |  |
| 42 | 2.3.1 | Интервью с заказчиком проекта |  | 0.25d | 2018-01-04 16:00 | 2018-01-04 18:00 | 40 | 0d | Эксперт-консультант | 1h | Видеозапись интервью |
| 43 | 2.3.2 | Интервью с руководителем проекта |  | 0.25d | 2018-01-05 09:00 | 2018-01-05 11:00 | 42 | 0d | Эксперт-консультант | 1h | Видеозапись интервью |
| 44 | 2.3.3 | Интервью с функциональными экспертами |  | 0.5d | 2018-01-05 11:00 | 2018-01-05 16:00 | 43 | 0d | Эксперт-консультант | 3h | Видеозапись интервью |
| 45 | 2.3.4 | Подготовка протоколов интервью, написание отчета |  | 0.25d | 2018-01-05 16:00 | 2018-01-05 18:00 | 44 | 0d | Эксперт-консультант | 2h | Протоколы интервью |
| 46 | 2.3.5 | Интервью проведены | milestone | 0d | 2018-01-05 18:00 | 2018-01-05 18:00 | 45 | 0d |  |  |  |
| 47 | 2.4 | **Подготовка отчета по диагностике** |  | 1.25d | 2018-01-08 09:00 | 2018-01-09 11:00 |  | 0d |  | 7h |  |
| 48 | 2.4.1 | Подготовка диагностического отчета по итогам обследования |  | 0.25d | 2018-01-08 09:00 | 2018-01-08 11:00 | 46 | 0d | Эксперт-консультант | 2h |  |
| 49 | 2.4.2 | Консультационная сессия: презентация и защита отчета по диагностике |  | 0.25d | 2018-01-08 11:00 | 2018-01-08 13:00 | 48 | 0d | Эксперт-консультант | 1h | Видеозапись консультации |
| 50 | 2.4.3 | Согласование отчета |  | 0.25d | 2018-01-08 14:00 | 2018-01-08 16:00 | 49 | 0d | Руководитель проекта | 2h |  |
| 51 | 2.4.4 | Внесение корректировок в отчет |  | 0.25d | 2018-01-08 16:00 | 2018-01-08 18:00 | 50 | 0d | Эксперт-консультант | 1h |  |
| 52 | 2.4.5 | Утверждение отчета |  | 0.25d | 2018-01-09 09:00 | 2018-01-09 11:00 | 51 | 0d | Заказчик | 1h | Отчет по диагностике |
| 53 | 2.4.6 | Отчет по диагностике утвержден | milestone | 0d | 2018-01-09 11:00 | 2018-01-09 11:00 | 52 | 0d |  |  |  |
| 54 | 2.5 | Обследование компании выполнено | milestone | 0d | 2018-01-09 11:00 | 2018-01-09 11:00 | 53 | 0d |  |  |  |

| ID | WBS | Task | Type | Duration | Start | Finish | Predecessors | Total slack | Resources | Work | Text1 |
| --- | --- | --- | --- | --- | --- | --- | --- | --- | --- | --- | --- |
| 55 | 3 | **Передача технологии** |  | 13.25d | 2018-01-09 11:00 | 2018-01-26 13:00 |  | 0d |  | 60h |  |
| 56 | 3.1 | **Стандарт "Соглашение о моделировании"** |  | 1.75d | 2018-01-09 11:00 | 2018-01-10 18:00 |  | 0d |  | 10h |  |
| 57 | 3.1.1 | Консультационная сессия о подходах к моделированию бизнес-процессов |  | 0.25d | 2018-01-09 11:00 | 2018-01-09 13:00 | 54 | 0d | Эксперт-консультант | 1h | Видеозапись консультации |
| 58 | 3.1.2 | Адаптация типового Стандарта "Соглашение о моделировании" |  | 0.5d | 2018-01-09 14:00 | 2018-01-09 18:00 | 57 | 0d | Эксперт-консультант | 4h |  |
| 59 | 3.1.3 | Консультационная сессия: презентация и защита Стандарта "Соглашение о моделировании" |  | 0.25d | 2018-01-10 09:00 | 2018-01-10 11:00 | 58 | 0d | Эксперт-консультант | 1h | Видеозапись консультации |
| 60 | 3.1.4 | Согласование Стандарта "Соглашение о моделировании" |  | 0.25d | 2018-01-10 11:00 | 2018-01-10 13:00 | 59 | 0d | Руководитель проекта | 2h |  |
| 61 | 3.1.5 | Внесение корректировок в Стандарт "Соглашение о моделировании" |  | 0.25d | 2018-01-10 14:00 | 2018-01-10 16:00 | 60 | 0d | Эксперт-консультант | 1h |  |
| 62 | 3.1.6 | Утверждение Стандарта "Соглашение о моделировании" |  | 0.25d | 2018-01-10 16:00 | 2018-01-10 18:00 | 61 | 0d | Заказчик | 1h |  |
| 63 | 3.1.7 | Стандарт "Соглашение о моделировании" утвержден | milestone | 0d | 2018-01-10 18:00 | 2018-01-10 18:00 | 62 | 0d |  |  | Стандарт "Соглашение о моделировании" |
| 64 | 3.2 | **Стандарт "Организация работ по описанию процессов"** |  | 1.75d | 2018-01-11 09:00 | 2018-01-12 16:00 |  | 0d |  | 10h |  |
| 65 | 3.2.1 | Консультационная сессия о способах организации работ по описанию процессов |  | 0.25d | 2018-01-11 09:00 | 2018-01-11 11:00 | 63 | 0d | Эксперт-консультант | 1h | Видеозапись консультации |
| 66 | 3.2.2 | Адаптация типового Стандарта "Организация работ по описанию процессов" |  | 0.5d | 2018-01-11 11:00 | 2018-01-11 16:00 | 65 | 0d | Эксперт-консультант | 4h |  |
| 67 | 3.2.3 | Консультационная сессия: презентация и защита Стандарта "Организация работ по описанию процессов" |  | 0.25d | 2018-01-11 16:00 | 2018-01-11 18:00 | 66 | 0d | Эксперт-консультант | 1h | Видеозапись консультации |
| 68 | 3.2.4 | Согласование Стандарта "Организация работ по описанию процессов" |  | 0.25d | 2018-01-12 09:00 | 2018-01-12 11:00 | 67 | 0d | Руководитель проекта | 2h |  |
| 69 | 3.2.5 | Внесение корректировок в Стандарт "Организация работ по описанию процессов" |  | 0.25d | 2018-01-12 11:00 | 2018-01-12 13:00 | 68 | 0d | Эксперт-консультант | 1h |  |
| 70 | 3.2.6 | Утверждение Стандарта "Организация работ по описанию процессов" |  | 0.25d | 2018-01-12 14:00 | 2018-01-12 16:00 | 69 | 0d | Заказчик | 1h |  |
| 71 | 3.2.7 | Стандарт "Организация работ по описанию процессов" утвержден | milestone | 0d | 2018-01-12 16:00 | 2018-01-12 16:00 | 70 | 0d |  |  | Стандарт "Организация работ по описанию процессов" |
| 72 | 3.3 | **Стандарт "Управление внутренними нормативными документами" (ВНД)** |  | 2.25d | 2018-01-12 16:00 | 2018-01-16 18:00 |  | 0d |  | 10h |  |
| 73 | 3.3.1 | Консультационная сессия о подходах к управлению ВНД |  | 0.25d | 2018-01-12 16:00 | 2018-01-12 18:00 | 71 | 0d | Эксперт-консультант | 1h | Видеозапись консультации |
| 74 | 3.3.2 | Адаптация типового Стандарта "Управление ВНД" |  | 1d | 2018-01-15 09:00 | 2018-01-15 18:00 | 73 | 0d | Эксперт-консультант | 4h |  |
| 75 | 3.3.3 | Консультационная сессия: презентация и защита Стандарта "Управление ВНД" |  | 0.25d | 2018-01-16 09:00 | 2018-01-16 11:00 | 74 | 96.25d | Эксперт-консультант | 1h | Видеозапись консультации |
| 76 | 3.3.4 | Согласование Стандарта "Управление ВНД" |  | 0.5d | 2018-01-16 09:00 | 2018-01-16 13:00 | 74 | 0d | Руководитель проекта | 2h |  |
| 77 | 3.3.5 | Внесение корректировок в Стандарт "Управление ВНД" |  | 0.25d | 2018-01-16 14:00 | 2018-01-16 16:00 | 76 | 0d | Эксперт-консультант | 1h |  |
| 78 | 3.3.6 | Утверждение Стандарта "Управление ВНД" |  | 0.25d | 2018-01-16 16:00 | 2018-01-16 18:00 | 77 | 0d | Заказчик | 1h |  |
| 79 | 3.3.7 | Стандарт "Управление ВНД" утвержден | milestone | 0d | 2018-01-16 18:00 | 2018-01-16 18:00 | 78 | 0d |  |  | Стандарт "Управление ВНД" |

| ID | WBS | Task | Type | Duration | Start | Finish | Predecessors | Total slack | Resources | Work | Text1 |
| --- | --- | --- | --- | --- | --- | --- | --- | --- | --- | --- | --- |
| 80 | 3.4 | **Стандарт "Руководство по оптимизации процессов"** |  | 2.5d | 2018-01-17 09:00 | 2018-01-19 13:00 |  | 0d |  | 10h |  |
| 81 | 3.4.1 | Консультационная сессия об организации работ по оптимизации процессов |  | 0.25d | 2018-01-17 09:00 | 2018-01-17 11:00 | 79 | 0d | Эксперт-консультант | 1h | Видеозапись консультации |
| 82 | 3.4.2 | Адаптация типового Стандарта "Руководство по оптимизации процессов" |  | 1d | 2018-01-17 11:00 | 2018-01-18 11:00 | 81 | 0d | Эксперт-консультант | 4h |  |
| 83 | 3.4.3 | Консультационная сессия: презентация и защита Стандарта "Руководство по оптимизации процессов" |  | 0.25d | 2018-01-18 11:00 | 2018-01-18 13:00 | 82 | 0d | Эксперт-консультант | 1h | Видеозапись консультации |
| 84 | 3.4.4 | Согласование Стандарта "Руководство по оптимизации процессов" |  | 0.5d | 2018-01-18 14:00 | 2018-01-18 18:00 | 83 | 0d | Руководитель проекта | 2h |  |
| 85 | 3.4.5 | Внесение корректировок в Стандарт "Руководство по оптимизации процессов" |  | 0.25d | 2018-01-19 09:00 | 2018-01-19 11:00 | 84 | 0d | Эксперт-консультант | 1h |  |
| 86 | 3.4.6 | Утверждение Стандарта "Руководство по оптимизации процессов" |  | 0.25d | 2018-01-19 11:00 | 2018-01-19 13:00 | 85 | 0d | Заказчик | 1h |  |
| 87 | 3.4.7 | Стандарт "Руководство по оптимизации процессов" утвержден | milestone | 0d | 2018-01-19 13:00 | 2018-01-19 13:00 | 86 | 0d |  |  | Стандарт "Руководство по оптимизации процессов" |
| 88 | 3.5 | **Разработка прототипов отчетов по модели процессов** |  | 5d | 2018-01-19 14:00 | 2018-01-26 13:00 |  | 0d |  | 20h |  |
| 89 | 3.5.1 | **Формирование требований к отчетам** |  | 1.5d | 2018-01-19 14:00 | 2018-01-22 18:00 |  | 0d |  | 6h |  |
| 90 | 3.5.1.1 | Консультация: Формирование требований к отчету "Описание процесса" |  | 0.25d | 2018-01-19 14:00 | 2018-01-19 16:00 | 87 | 0d | Эксперт-консультант | 1h | Видеозапись консультации |
| 91 | 3.5.1.2 | Консультация: Формирование требований к отчету "Регламент процесса" |  | 0.25d | 2018-01-19 16:00 | 2018-01-19 18:00 | 90 | 0d | Эксперт-консультант | 1h | Видеозапись консультации |
| 92 | 3.5.1.3 | Консультация: Формирование требований к отчету "Рабочая инструкция" |  | 0.25d | 2018-01-22 09:00 | 2018-01-22 11:00 | 91 | 0d | Эксперт-консультант | 1h | Видеозапись консультации |
| 93 | 3.5.1.4 | Консультация: Формирование требований к отчету "Должностная инструкция" |  | 0.25d | 2018-01-22 11:00 | 2018-01-22 13:00 | 92 | 0d | Эксперт-консультант | 1h | Видеозапись консультации |
| 94 | 3.5.1.5 | Консультация: Формирование требований к отчету "Положение о подразделении" |  | 0.25d | 2018-01-22 14:00 | 2018-01-22 16:00 | 93 | 0d | Эксперт-консультант | 1h | Видеозапись консультации |
| 95 | 3.5.1.6 | Консультация: Формирование требований к отчету "Требования по автоматизации" |  | 0.25d | 2018-01-22 16:00 | 2018-01-22 18:00 | 94 | 0d | Эксперт-консультант | 1h | Видеозапись консультации |
| 96 | 3.5.1.7 | Требования к отчетам сформированы | milestone | 0d | 2018-01-22 18:00 | 2018-01-22 18:00 | 95 | 0d |  |  | Документ: Требования к отчетам |
| 97 | 3.5.2 | **Разработка прототипов отчетов** |  | 1.5d | 2018-01-23 09:00 | 2018-01-24 13:00 |  | 0d |  | 6h |  |
| 98 | 3.5.2.1 | Разработка прототипа отчета "Описание процесса" |  | 0.25d | 2018-01-23 09:00 | 2018-01-23 11:00 | 96 | 0d | Эксперт-консультант | 1h |  |
| 99 | 3.5.2.2 | Разработка прототипа отчета "Регламент процесса" |  | 0.25d | 2018-01-23 11:00 | 2018-01-23 13:00 | 98 | 0d | Эксперт-консультант | 1h |  |
| 100 | 3.5.2.3 | Разработка прототипа отчета "Рабочая инструкция" |  | 0.25d | 2018-01-23 14:00 | 2018-01-23 16:00 | 99 | 0d | Эксперт-консультант | 1h |  |
| 101 | 3.5.2.4 | Разработка прототипа отчета "Должностная инструкция" |  | 0.25d | 2018-01-23 16:00 | 2018-01-23 18:00 | 100 | 0d | Эксперт-консультант | 1h |  |
| 102 | 3.5.2.5 | Разработка прототипа отчета "Положение о подразделении" |  | 0.25d | 2018-01-24 09:00 | 2018-01-24 11:00 | 101 | 0d | Эксперт-консультант | 1h |  |
| 103 | 3.5.2.6 | Разработка прототипа отчета "Требования по автоматизации" |  | 0.25d | 2018-01-24 11:00 | 2018-01-24 13:00 | 102 | 0d | Эксперт-консультант | 1h |  |
| 104 | 3.5.2.7 | Прототипы отчетов разработаны | milestone | 0d | 2018-01-24 13:00 | 2018-01-24 13:00 | 103 | 0d |  |  |  |

| ID | WBS | Task | Type | Duration | Start | Finish | Predecessors | Total slack | Free slack | Resources | Work | Text1 |
| --- | --- | --- | --- | --- | --- | --- | --- | --- | --- | --- | --- | --- |
| 105 | 3.5.3 | **Согласование прототипов отчетов** |  | 2d | 2018-01-24 14:00 | 2018-01-26 13:00 |  | 0d |  |  | 8h |  |
| 106 | 3.5.3.1 | Консультационная сессия: презентация и защита прототипов отчетов |  | 0.25d | 2018-01-24 14:00 | 2018-01-24 16:00 | 104 | 0d |  | Эксперт-консультант | 1h | Видеозапись консультации |
| 107 | 3.5.3.2 | Согласование прототипов отчетов |  | 1d | 2018-01-24 16:00 | 2018-01-25 16:00 | 106 | 0d |  | Руководитель проекта | 4h |  |
| 108 | 3.5.3.3 | Внесение корректировок в прототипы отчетов |  | 0.5d | 2018-01-25 16:00 | 2018-01-26 11:00 | 107 | 0d |  | Эксперт-консультант | 2h |  |
| 109 | 3.5.3.4 | Утверждение прототипов отчетов |  | 0.25d | 2018-01-26 11:00 | 2018-01-26 13:00 | 108 | 0d |  | Заказчик | 1h |  |
| 110 | 3.5.4 | Прототипы отчетов утрвеждены | milestone | 0d | 2018-01-26 13:00 | 2018-01-26 13:00 | 109 | 0d |  |  |  | Прототипы отчетов с указанием привязок к модели |
| 111 | 3.6 | Технология передана | milestone | 0d | 2018-01-26 13:00 | 2018-01-26 13:00 | 110 | 0d |  |  |  |  |
| 112 | 4 | **Настройка системы моделирования** |  | 8.25d | 2018-01-26 14:00 | 2018-02-07 16:00 |  | 1.75d |  |  | 43h |  |
| 113 | 4.1 | **Установка и лицензирование** |  | 1.75d | 2018-01-26 14:00 | 2018-01-30 11:00 |  | 1.75d |  |  | 7h |  |
| 114 | 4.1.1 | Консультация по выбору информационной системы и лицензированию |  | 0.25d | 2018-01-26 14:00 | 2018-01-26 16:00 | 111 | 1.75d | 0d | Эксперт-консультант | 1h | Видеозапись консультации |
| 115 | 4.1.2 | Закупка системы моделирования |  | 0.5d | 2018-01-26 16:00 | 2018-01-29 11:00 | 114 | 1.75d | 0d | Заказчик | 2h |  |
| 116 | 4.1.3 | Установка системы моделирования |  | 0.5d | 2018-01-29 11:00 | 2018-01-29 16:00 | 115 | 1.75d | 0d | Эксперт-консультант | 2h |  |
| 117 | 4.1.4 | Настройка лицензий: закупленных лицензий и временных проектных лицензий |  | 0.5d | 2018-01-29 16:00 | 2018-01-30 11:00 | 116 | 1.75d | 0d | Эксперт-консультант | 2h |  |
| 118 | 4.1.5 | Система моделирования установлена | milestone | 0d | 2018-01-30 11:00 | 2018-01-30 11:00 | 117 | 1.75d | 0d |  |  |  |
| 119 | 4.2 | **Настройка доступа к системе моделирования** |  | 2d | 2018-01-30 11:00 | 2018-02-01 11:00 |  | 1.75d |  |  | 8h |  |
| 120 | 4.2.1 | Консультация по настройке прав доступа |  | 0.25d | 2018-01-30 11:00 | 2018-01-30 13:00 | 118 | 1.75d | 0d | Эксперт-консультант | 1h | Видеозапись консультации |
| 121 | 4.2.2 | Формирование таблицы прав доступа (RLS) |  | 0.25d | 2018-01-30 14:00 | 2018-01-30 16:00 | 120 | 1.75d | 0d | Эксперт-консультант | 1h |  |
| 122 | 4.2.3 | Согласование таблицы прав доступа |  | 0.5d | 2018-01-30 16:00 | 2018-01-31 11:00 | 121 | 1.75d | 0d | Руководитель проекта | 2h |  |
| 123 | 4.2.4 | Внесение корректировок в таблицу прав доступа |  | 0.25d | 2018-01-31 11:00 | 2018-01-31 13:00 | 122 | 1.75d | 0d | Эксперт-консультант | 1h |  |
| 124 | 4.2.5 | Утверждение таблицы прав доступа |  | 0.25d | 2018-01-31 14:00 | 2018-01-31 16:00 | 123 | 1.75d | 0d | Заказчик | 1h |  |
| 125 | 4.2.6 | Настройка прав доступа в соответствии с утвержденной таблицей |  | 0.5d | 2018-01-31 16:00 | 2018-02-01 11:00 | 124 | 1.75d | 0d | Эксперт-консультант | 2h |  |
| 126 | 4.2.7 | Настроен доступ к системе моделирования | milestone | 0d | 2018-02-01 11:00 | 2018-02-01 11:00 | 125 | 1.75d | 0d |  |  | Таблица прав доступа к системе моделирования |
| 127 | 4.3 | **Настройка дополнительных полей** |  | 1d | 2018-02-01 11:00 | 2018-02-02 11:00 |  | 1.75d |  |  | 4h |  |
| 128 | 4.3.1 | Настройка дополнительных полей в соответствии с прототипами отчетов |  | 0.5d | 2018-02-01 11:00 | 2018-02-01 16:00 | 126 | 1.75d | 0d | Эксперт-консультант | 2h | Копия базы системы моделирования с настроенными доп. полями |
| 129 | 4.3.2 | Тестирование работы дополнительных полей |  | 0.5d | 2018-02-01 16:00 | 2018-02-02 11:00 | 128 | 1.75d | 0d | Эксперт-консультант | 2h |  |
| 130 | 4.3.3 | Дополнительные поля настроены | milestone | 0d | 2018-02-02 11:00 | 2018-02-02 11:00 | 129 | 1.75d | 0d |  |  | Документ: Перечень и свойства дополнительных полей |

| ID | WBS | Task | Type | Duration | Start | Finish | Predecessors | Total slack | Free slack | Resources | Work | Text1 |
| --- | --- | --- | --- | --- | --- | --- | --- | --- | --- | --- | --- | --- |
| 131 | 4.4 | **Настройка отчетов по модели процессов** |  | 3.5d | 2018-02-02 11:00 | 2018-02-07 16:00 |  | 1.75d |  |  | 24h |  |
| 132 | 4.4.1 | Настройка отчетов в соответствии с прототипами |  | 2.5d | 2018-02-02 11:00 | 2018-02-06 16:00 | 130 | 1.75d | 0d | Эксперт-консультант | 18h |  |
| 133 | 4.4.2 | Тестирование работы отчетов на пробном процессе |  | 1d | 2018-02-06 16:00 | 2018-02-07 16:00 | 132 | 1.75d | 0d | Эксперт-консультант | 6h |  |
| 134 | 4.4.3 | Отчеты по модели процессов настроены | milestone | 0d | 2018-02-07 16:00 | 2018-02-07 16:00 | 133 | 1.75d | 0d |  |  | Копия базы системы моделирования с настроенными отчетами |
| 135 | 4.5 | Система моделирования настроена | milestone | 0d | 2018-02-07 16:00 | 2018-02-07 16:00 | 134 | 1.75d |  |  |  |  |
| 136 | 5 | **Проведение обучения** |  | 10d | 2018-01-26 14:00 | 2018-02-09 13:00 |  | 0d |  |  | 63.5h |  |
| 137 | 5.1 | **Подготовка обучения** |  | 1.5d | 2018-01-26 14:00 | 2018-01-29 18:00 |  | 0d |  |  | 5.5h |  |
| 138 | 5.1.1 | Консультационная сессия по планированию, подготовке и организации обучения |  | 0.25d | 2018-01-26 14:00 | 2018-01-26 16:00 | 111 | 0d |  | Эксперт-консультант | 0.5h | Видеозапись консультации |
| 139 | 5.1.2 | Составление плана обучения и корректировка программ обучения |  | 0.25d | 2018-01-26 16:00 | 2018-01-26 18:00 | 138 | 0d |  | Эксперт-консультант | 1h |  |
| 140 | 5.1.3 | Консультационная сессия: презентация и защита плана и программы обучения |  | 0.25d | 2018-01-29 09:00 | 2018-01-29 11:00 | 139 | 0d |  | Эксперт-консультант | 0.5h | Видеозапись консультации |
| 141 | 5.1.4 | Согласование плана и программ обучения |  | 0.25d | 2018-01-29 11:00 | 2018-01-29 13:00 | 140 | 0d |  | Руководитель проекта | 2h |  |
| 142 | 5.1.5 | Внесение корректировок в план и программы обучения |  | 0.25d | 2018-01-29 14:00 | 2018-01-29 16:00 | 141 | 0d |  | Эксперт-консультант | 0.5h |  |
| 143 | 5.1.6 | Утверждение плана и программ обучения |  | 0.25d | 2018-01-29 16:00 | 2018-01-29 18:00 | 142 | 0d |  | Заказчик | 1h |  |
| 144 | 5.1.7 | Подготовка обучения выполнена | milestone | 0d | 2018-01-29 18:00 | 2018-01-29 18:00 | 143 | 0d |  |  |  | План обучения |
| 145 | 5.2 | **Проведение обучения** |  | 7d | 2018-01-30 09:00 | 2018-02-07 18:00 |  | 0d |  |  | 52h |  |
| 146 | 5.2.1 | Обучение руководителей (процессное управление, чтение диаграмм, организация работ, оптимизация процессов) |  | 2d | 2018-01-30 09:00 | 2018-01-31 18:00 | 144 | 0d |  | Бизнес-тренер | 16h | Видеозапись обучения |
| 147 | 5.2.2 | Обучение сотрудников (чтение диаграмм, использование нормативных документов, работа с автоматизированными сисиемами) |  | 1d | 2018-02-01 09:00 | 2018-02-01 18:00 | 146 | 0d |  | Бизнес-тренер | 8h | Видеозапись обучения |
| 148 | 5.2.3 | Обучение бизнес-аналитиков (моделирование процессов, формирование нормативных документов, участие в автоматизации) |  | 3d | 2018-02-02 09:00 | 2018-02-06 18:00 | 147 | 0d |  | Бизнес-тренер | 24h | Видеозапись обучения |
| 149 | 5.2.4 | Обучение ИТ-специалистов (администрирование баз данных системы моделирования бизнес-процессов) |  | 1d | 2018-02-07 09:00 | 2018-02-07 18:00 | 148 | 0d |  | Бизнес-тренер | 4h | Видеозапись обучения |
| 150 | 5.2.5 | Обучение проведено | milestone | 0d | 2018-02-07 18:00 | 2018-02-07 18:00 | 149 | 0d |  |  |  | Протокол явки на обучение |
| 151 | 5.3 | **Оценка по итогам обучения** |  | 1.5d | 2018-02-08 09:00 | 2018-02-09 13:00 |  | 0d |  |  | 6h |  |
| 152 | 5.3.1 | Консультационная сессия: выдача заданий для оценки |  | 0.25d | 2018-02-08 09:00 | 2018-02-08 11:00 | 150 | 0d |  | Эксперт-консультант | 1h | Видеозапись консультации |
| 153 | 5.3.2 | Проверка выполнения заданий |  | 1d | 2018-02-08 11:00 | 2018-02-09 11:00 | 152 | 0d |  | Эксперт-консультант | 4h |  |
| 154 | 5.3.3 | Формирование оценочного протокола |  | 0.25d | 2018-02-09 11:00 | 2018-02-09 13:00 | 153 | 0d |  | Эксперт-консультант | 1h |  |
| 155 | 5.3.4 | Оценка по итогам обучения выполнена | milestone | 0d | 2018-02-09 13:00 | 2018-02-09 13:00 | 154 | 0d |  |  |  | Оценочный протокол |
| 156 | 5.4 | Этап обучения завершен | milestone | 0d | 2018-02-09 13:00 | 2018-02-09 13:00 | 155 | 0d |  |  |  |  |

| ID | WBS | Task | Type | Duration | Start | Finish | Predecessors | Total slack | Resources | Work |
| --- | --- | --- | --- | --- | --- | --- | --- | --- | --- | --- |
| 157 | 6 | **Моделирование бизнес-процессов** |  | 33.5d | 2018-02-09 14:00 | 2018-03-28 18:00 |  | 0d |  | 132h |
| 158 | 6.1 | **Перенос организационной структуры** |  | 2.75d | 2018-02-09 14:00 | 2018-02-14 11:00 |  | 0d |  | 13h |
| 159 | 6.1.1 | Консультация по переносу организационной структуры |  | 0.25d | 2018-02-09 14:00 | 2018-02-09 16:00 | 156, 135 | 0d | Эксперт-консультант | 1h |
| 160 | 6.1.2 | Перенос организационной структуры в систему моделирования |  | 0.5d | 2018-02-09 16:00 | 2018-02-12 11:00 | 159 | 0d | Эксперт-консультант | 3h |
| 161 | 6.1.3 | Создание организационной диаграммы в системе моделирования |  | 0.5d | 2018-02-12 11:00 | 2018-02-12 16:00 | 160 | 0d | Эксперт-консультант | 3h |
| 162 | 6.1.4 | Консультационная сессия: презентация и защита организационной диаграммы |  | 0.25d | 2018-02-12 16:00 | 2018-02-12 18:00 | 161 | 0d | Эксперт-консультант | 1h |
| 163 | 6.1.5 | Согласование организационной диаграмммы |  | 0.5d | 2018-02-13 09:00 | 2018-02-13 13:00 | 162 | 0d | Руководитель проекта | 2h |
| 164 | 6.1.6 | Выполнение корректировок организационной диаграммы |  | 0.25d | 2018-02-13 14:00 | 2018-02-13 16:00 | 163 | 0d | Эксперт-консультант | 1h |
| 165 | 6.1.7 | Утверждение организационной диаграммы |  | 0.5d | 2018-02-13 16:00 | 2018-02-14 11:00 | 164 | 0d | Заказчик | 2h |
| 166 | 6.1.8 | Организационная структура перенесена в систему моделирования | milestone | 0d | 2018-02-14 11:00 | 2018-02-14 11:00 | 165 | 0d |  |  |
| 167 | 6.2 | **Создание диаграмм верхнего уровня** |  | 5d | 2018-02-14 11:00 | 2018-02-21 11:00 |  | 0d |  | 26h |
| 168 | 6.2.1 | Консультационные сессии с ключевыми руководителями (сбор данных SADT) |  | 1d | 2018-02-14 11:00 | 2018-02-15 11:00 | 166 | 0d | Эксперт-консультант | 8h |
| 169 | 6.2.2 | Построение контекстной диаграммы (A-0) |  | 0.25d | 2018-02-15 11:00 | 2018-02-15 13:00 | 168 | 0d | Эксперт-консультант | 1h |
| 170 | 6.2.3 | Построение функциональной диаграммы верхнего уровня (A0) |  | 0.5d | 2018-02-15 14:00 | 2018-02-15 18:00 | 169 | 0d | Эксперт-консультант | 2h |
| 171 | 6.2.4 | Построение функциональных диаграмм первого уровня декомпозиции (An) |  | 2d | 2018-02-16 09:00 | 2018-02-19 18:00 | 170 | 0d | Эксперт-консультант | 8h |
| 172 | 6.2.5 | Консультационная сессия: презентация и защита функциональных диаграмм верхнего уровня |  | 0.25d | 2018-02-20 09:00 | 2018-02-20 11:00 | 171 | 0d | Эксперт-консультант | 1h |
| 173 | 6.2.6 | Согласование функциональных диаграмм верхнего уровня |  | 0.25d | 2018-02-20 11:00 | 2018-02-20 13:00 | 172 | 0d | Руководитель проекта | 2h |
| 174 | 6.2.7 | Выполнение корректировок функциональных диаграмм верхнего уровня |  | 0.5d | 2018-02-20 14:00 | 2018-02-20 18:00 | 173 | 0d | Эксперт-консультант | 2h |
| 175 | 6.2.8 | Утверждение функциональных диаграмм верхнего уровня |  | 0.25d | 2018-02-21 09:00 | 2018-02-21 11:00 | 174 | 0d | Заказчик | 2h |
| 176 | 6.2.9 | Функциональные диаграммы верхнего уровня утверждены | milestone | 0d | 2018-02-21 11:00 | 2018-02-21 11:00 | 175 | 0d |  |  |
| 177 | 6.3 | **Составление справочника бизнес-процессов** |  | 7.75d | 2018-02-21 11:00 | 2018-03-02 18:00 |  | 0d |  | 35h |
| 178 | 6.3.1 | Консультационные сессии с руководителями подразделений: сбор информации |  | 1d | 2018-02-21 11:00 | 2018-02-22 11:00 | 176 | 0d | Эксперт-консультант | 8h |
| 179 | 6.3.2 | Составление справочника бизнес-процессов |  | 2d | 2018-02-22 11:00 | 2018-02-26 11:00 | 178 | 0d | Эксперт-консультант | 8h |
| 180 | 6.3.3 | Консультационные сессии с руководителями подразделений: согласование списков бизнес-процессов |  | 1d | 2018-02-26 11:00 | 2018-02-27 11:00 | 179 | 0d | Эксперт-консультант | 4h |
| 181 | 6.3.4 | Согласование списков бизнес-процессов по подразделениям (по функциям) |  | 2d | 2018-02-27 11:00 | 2018-03-01 11:00 | 180 | 0d | Функциональный эксперт | 8h |
| 182 | 6.3.5 | Консультационная сессия: презентация и защита справочника бизнес-процессов |  | 0.25d | 2018-03-01 11:00 | 2018-03-01 13:00 | 181 | 0d | Эксперт-консультант | 1h |
| 183 | 6.3.6 | Согласование справочника бизнес-процессов |  | 0.5d | 2018-03-01 14:00 | 2018-03-01 18:00 | 182 | 0d | Руководитель проекта | 2h |
| 184 | 6.3.7 | Выполнение корректировок справочника бизнес-процессов |  | 0.5d | 2018-03-02 09:00 | 2018-03-02 13:00 | 183 | 0d | Эксперт-консультант | 2h |
| 185 | 6.3.8 | Утверждение справочника бизнес-процессов |  | 0.5d | 2018-03-02 14:00 | 2018-03-02 18:00 | 184 | 0d | Заказчик | 2h |
| 186 | 6.3.9 | Справочник бизнес-процессов утвержден | milestone | 0d | 2018-03-02 18:00 | 2018-03-02 18:00 | 185 | 0d |  |  |

Notes:
- 159: Text1: Видеозапись консультации
- 162: Text1: Видеозапись консультации
- 165: Text1: Организационная диаграмма
- 166: Text1: Копия базы системы моделирования с организационной структурой
- 168: Text1: Видеозапись консультации
- 169: Text1: Диаграмма окружения процессной модели
- 170: Text1: Диаграмма ключевых функций и цепочек создания ценности
- 171: Text1: Диаграммы, отражающие содержание ключевых функций
- 172: Text1: Видеозапись консультации
- 176: Text1: Функциональные диаграммы верхнего уровня (A-0, A0, An)
- 178: Text1: Видеозапись консультации
- 180: Text1: Видеозапись консультации
- 181: Text1: Списки бизнес-процессов в разрезе по функциям
- 182: Text1: Видеозапись консультации
- 186: Text1: Единый справочник бизнес-процессов

| ID | WBS | Task | Type | Duration | Start | Finish | Predecessors | Total slack | Resources | Work | Text1 |
| --- | --- | --- | --- | --- | --- | --- | --- | --- | --- | --- | --- |
| 187 | 6.4 | **Моделирование бизнес-процессов / функций** |  | 2.75d | 2018-03-05 09:00 | 2018-03-07 16:00 |  | 0d |  | 15h |  |
| 188 | 6.4.1 | **Процесс / Функция 1, 2, 3 … N** |  | 2.75d | 2018-03-05 09:00 | 2018-03-07 16:00 |  | 0d |  | 15h |  |
| 189 | 6.4.1.1 | Консультационная сессия: сбор исходных данных для моделирования |  | 0.25d | 2018-03-05 09:00 | 2018-03-05 11:00 | 186 | 0d | Эксперт-консультант | 2h | Видеозапись консультации |
| 190 | 6.4.1.2 | Моделирование бизнес-процесса / функции |  | 0.5d | 2018-03-05 11:00 | 2018-03-05 16:00 | 189 | 0d | Эксперт-консультант | 4h |  |
| 191 | 6.4.1.3 | Консультационная сессия: презентация и защита модели бизнес-процесса / функции |  | 0.25d | 2018-03-05 16:00 | 2018-03-05 18:00 | 190 | 0d | Эксперт-консультант | 1h | Видеозапись консультации |
| 192 | 6.4.1.4 | Согласование модели процесса / функции |  | 0.5d | 2018-03-06 09:00 | 2018-03-06 13:00 | 191 | 0d | Функциональный эксперт | 2h |  |
| 193 | 6.4.1.5 | Согласование модели процесса / функции |  | 0.5d | 2018-03-06 14:00 | 2018-03-06 18:00 | 192 | 0d | Руководитель проекта | 2h |  |
| 194 | 6.4.1.6 | Выполнение корректировок модели процесса / функции |  | 0.25d | 2018-03-07 09:00 | 2018-03-07 11:00 | 193 | 0d | Эксперт-консультант | 2h |  |
| 195 | 6.4.1.7 | Утверждение модели процесса / функции |  | 0.5d | 2018-03-07 11:00 | 2018-03-07 16:00 | 194 | 0d | Заказчик | 2h |  |
| 196 | 6.4.1.8 | Модель бизнес-процесса / функции утверждена | milestone | 0d | 2018-03-07 16:00 | 2018-03-07 16:00 | 195 | 0d |  |  | Модель бизнес-процесса |
| 197 | 6.5 | **Согласование единой процессной модели** |  | 8d | 2018-03-07 16:00 | 2018-03-19 16:00 |  | 0d |  | 28h |  |
| 198 | 6.5.1 | Консультационная сессия: презентация и защита единой процессной модели |  | 0.5d | 2018-03-07 16:00 | 2018-03-08 11:00 | 196 | 0d | Эксперт-консультант | 2h | Видеозапись консультации |
| 199 | 6.5.2 | Согласование единой процессной модели |  | 5d | 2018-03-08 11:00 | 2018-03-15 11:00 | 198 | 0d | Руководитель проекта | 16h |  |
| 200 | 6.5.3 | Выполнение корректировок единой процессной модели |  | 2d | 2018-03-15 11:00 | 2018-03-19 11:00 | 199 | 0d | Эксперт-консультант | 8h |  |
| 201 | 6.5.4 | Утверждение единой процессной модели |  | 0.5d | 2018-03-19 11:00 | 2018-03-19 16:00 | 200 | 0d | Заказчик | 2h |  |
| 202 | 6.5.5 | Единая процессная модель утверждена | milestone | 0d | 2018-03-19 16:00 | 2018-03-19 16:00 | 201 | 0d |  |  | Копия базы системы моделирования с единой процессной моделью |
| 203 | 6.6 | **Формирование базы нормативных документов** |  | 7.25d | 2018-03-19 16:00 | 2018-03-28 18:00 |  | 0d |  | 15h |  |
| 204 | 6.6.1 | Консультационная сессия: определение списка нормативных документов |  | 0.25d | 2018-03-19 16:00 | 2018-03-19 18:00 | 202 | 0d | Эксперт-консультант | 1h | Видеозапись консультации |
| 205 | 6.6.2 | Формирование базы нормативных документов и их публикация |  | 2d | 2018-03-20 09:00 | 2018-03-21 18:00 | 204 | 0d | Эксперт-консультант | 6h |  |
| 206 | 6.6.3 | **Согласование нормативных документов с функциональными экспертами** |  | 2d | 2018-03-22 09:00 | 2018-03-23 18:00 |  | 0d |  | 3h |  |
| 207 | 6.6.3.1 | Согласование документа 1, 2, 3, N |  | 1d | 2018-03-22 09:00 | 2018-03-22 18:00 | 205 | 0d | Функциональный эксперт | 2h |  |
| 208 | 6.6.3.2 | Выполнение корректировок бизнес-процессов 1, 2, 3, N |  | 1d | 2018-03-23 09:00 | 2018-03-23 18:00 | 207 | 0d | Эксперт-консультант | 1h |  |
| 209 | 6.6.4 | **Согласование нормативных документов с руководителем проекта** |  | 2d | 2018-03-26 09:00 | 2018-03-27 18:00 |  | 0d |  | 3h |  |
| 210 | 6.6.4.1 | Согласование документа 1, 2, 3, N |  | 1d | 2018-03-26 09:00 | 2018-03-26 18:00 | 208 | 0d | Руководитель проекта | 2h |  |
| 211 | 6.6.4.2 | Выполнение корректировок бизнес-процессов 1, 2, 3, N |  | 1d | 2018-03-27 09:00 | 2018-03-27 18:00 | 210 | 0d | Эксперт-консультант | 1h |  |

| ID | WBS | Task | Type | Duration | Start | Finish | Predecessors | Total slack | Free slack | Resources | Work | Text1 |
| --- | --- | --- | --- | --- | --- | --- | --- | --- | --- | --- | --- | --- |
| 212 | 6.6.5 | **Утверждение нормативных документов** |  | 1d | 2018-03-28 09:00 | 2018-03-28 18:00 |  | 0d |  |  | 2h |  |
| 213 | 6.6.5.1 | Утверждение документа 1, 2, 3, N |  | 1d | 2018-03-28 09:00 | 2018-03-28 18:00 | 211 | 0d |  | Заказчик | 2h |  |
| 214 | 6.6.6 | База внутренних документов сформирована | milestone | 0d | 2018-03-28 18:00 | 2018-03-28 18:00 | 213 | 0d |  |  |  | База внутренних нормативных документов компании |
| 215 | 6.7 | Моделирование бизнес-процессов выполнено | milestone | 0d | 2018-03-28 18:00 | 2018-03-28 18:00 | 214 | 0d |  |  |  |  |
| 216 | 7 | **Разработка сбалансированной системы показателей** |  | 21.5d | 2018-03-29 09:00 | 2018-04-27 13:00 |  | 23.62d |  |  | 86h |  |
| 217 | 7.1 | **Разработка карты целей и показателей** |  | 6d | 2018-03-29 09:00 | 2018-04-05 18:00 |  | 23.62d |  |  | 17h |  |
| 218 | 7.1.1 | Консультационная сессия: определение целей и ключевых показателей деятельности по BSC |  | 0.5d | 2018-03-29 09:00 | 2018-03-29 13:00 | 215 | 25d | 0d | Эксперт-консультант | 2h | Видеозапись консультации |
| 219 | 7.1.2 | Разработка карты целей и показателей |  | 3d | 2018-03-29 14:00 | 2018-04-03 13:00 | 218 | 25d | 0d | Эксперт-консультант | 8h |  |
| 220 | 7.1.3 | Консультационная сессия: презентация и защита карты целей и показателей |  | 0.5d | 2018-04-03 14:00 | 2018-04-03 18:00 | 219 | 25d | 0d | Эксперт-консультант | 1h | Видеозапись консультации |
| 221 | 7.1.4 | Согласование карты целей и показателей |  | 0.5d | 2018-04-04 09:00 | 2018-04-04 13:00 | 220 | 25d | 0d | Руководитель проекта | 2h |  |
| 222 | 7.1.5 | Выполнение корректировок карты целей и показателей |  | 1d | 2018-04-04 14:00 | 2018-04-05 13:00 | 221 | 25d | 0d | Эксперт-консультант | 2h |  |
| 223 | 7.1.6 | Утверждение карты целей и показателей |  | 0.5d | 2018-04-05 14:00 | 2018-04-05 18:00 | 222 | 25d | 0d | Заказчик | 2h |  |
| 224 | 7.1.7 | Карта целей и показателей утверждена | milestone | 0d | 2018-04-05 18:00 | 2018-04-05 18:00 | 223 | 25d | 0d |  |  | Карта целей и показателей |
| 225 | 7.2 | **Разработка системы показателей KPI** |  | 7d | 2018-04-06 09:00 | 2018-04-16 18:00 |  | 23.62d |  |  | 31h |  |
| 226 | 7.2.1 | Анализ модели процессов, разработка системы показателей KPI |  | 3d | 2018-04-06 09:00 | 2018-04-10 18:00 | 224 | 23d | 0d | Эксперт-консультант | 16h |  |
| 227 | 7.2.2 | Консультационная сессия: презентация и защита системы показателей KPI |  | 0.5d | 2018-04-11 09:00 | 2018-04-11 13:00 | 226 | 23d | 0d | Эксперт-консультант | 1h | Видеозапись консультации |
| 228 | 7.2.3 | Согласование системы показателей KPI |  | 1d | 2018-04-11 14:00 | 2018-04-12 13:00 | 227 | 23d | 0d | Руководитель проекта | 4h |  |
| 229 | 7.2.4 | Выполнение корректировок системы показателей KPI |  | 2d | 2018-04-12 14:00 | 2018-04-16 13:00 | 228 | 23d | 0d | Эксперт-консультант | 8h |  |
| 230 | 7.2.5 | Утверждение системы показателей KPI |  | 0.5d | 2018-04-16 14:00 | 2018-04-16 18:00 | 229 | 23d | 0d | Заказчик | 2h |  |
| 231 | 7.2.6 | Система показателей KPI утверждена | milestone | 0d | 2018-04-16 18:00 | 2018-04-16 18:00 | 230 | 23d | 0d |  |  | Система показателей KPI |
| 232 | 7.3 | **Разработка отчетов для контроля KPI** |  | 8.5d | 2018-04-17 09:00 | 2018-04-27 13:00 |  | 23.62d |  |  | 38h |  |
| 233 | 7.3.1 | Разработка шаблонов отчетов для контроля KPI |  | 4d | 2018-04-17 09:00 | 2018-04-20 18:00 | 231 | 23d | 0d | Эксперт-консультант | 16h |  |
| 234 | 7.3.2 | Консультационная сессия: презентация и защита шаблонов отчетов для контроля KPI |  | 0.5d | 2018-04-23 09:00 | 2018-04-23 13:00 | 233 | 23d | 0d | Эксперт-консультант | 2h | Видеозапись консультации |
| 235 | 7.3.3 | Согласование шаблонов отчетов для контроля KPI |  | 1d | 2018-04-23 14:00 | 2018-04-24 13:00 | 234 | 23d | 0d | Руководитель проекта | 4h |  |
| 236 | 7.3.4 | Выполнение корректировок шаблонов отчетов для контроля KPI |  | 2d | 2018-04-24 14:00 | 2018-04-26 13:00 | 235 | 23d | 0d | Эксперт-консультант | 8h |  |
| 237 | 7.3.5 | Утверждение шаблонов отчетов для контроля KPI |  | 1d | 2018-04-26 14:00 | 2018-04-27 13:00 | 236 | 23d | 0d | Заказчик | 8h |  |
| 238 | 7.3.6 | Отчеты для контроля KPI утверждены | milestone | 0d | 2018-04-27 13:00 | 2018-04-27 13:00 | 237 | 23d | 0d |  |  | Отчеты для контроля KPI |
| 239 | 7.4 | Система сбалансированных показателей разработана | milestone | 0d | 2018-04-27 13:00 | 2018-04-27 13:00 | 238 | 23d |  |  |  |  |

| ID | WBS | Task | Type | Duration | Start | Finish | Predecessors | Total slack | Free slack | Resources | Work |
| --- | --- | --- | --- | --- | --- | --- | --- | --- | --- | --- | --- |
| 240 | 8 | **Оптимизация бизнес-процессов** |  | 22.5d | 2018-03-29 09:00 | 2018-04-30 13:00 |  | 22.62d |  |  | 106h |
| 241 | 8.1 | **Планирование оптимизации бизнес-процессов** |  | 2.25d | 2018-03-29 09:00 | 2018-04-02 11:00 |  | 22.62d |  |  | 9h |
| 242 | 8.1.1 | Консультационная сессия: составление плана (очередности) оптимизации бизнес-процессов |  | 0.25d | 2018-03-29 09:00 | 2018-03-29 11:00 | 215 | 22.62d | 0d | Эксперт-консультант | 1h |
| 243 | 8.1.2 | Составление плана по оптимизации бизнес-процессов |  | 0.5d | 2018-03-29 11:00 | 2018-03-29 16:00 | 242 | 22.62d | 0d | Эксперт-консультант | 2h |
| 244 | 8.1.3 | Консультационная сессия: презентация и защита плана по оптимизации бизнес-процессов |  | 0.25d | 2018-03-29 16:00 | 2018-03-29 18:00 | 243 | 22.62d | 0d | Эксперт-консультант | 1h |
| 245 | 8.1.4 | Согласование плана по оптимизации бизнес-процессов |  | 0.5d | 2018-03-30 09:00 | 2018-03-30 13:00 | 244 | 22.62d | 0d | Руководитель проекта | 2h |
| 246 | 8.1.5 | Выполнение корректировок плана по оптимизации бизнес-процессов |  | 0.25d | 2018-03-30 14:00 | 2018-03-30 16:00 | 245 | 22.62d | 0d | Эксперт-консультант | 1h |
| 247 | 8.1.6 | Утверждение плана по оптимизации бизнес-процессов |  | 0.5d | 2018-03-30 16:00 | 2018-04-02 11:00 | 246 | 22.62d | 0d | Заказчик | 2h |
| 248 | 8.1.7 | План по оптимизации бизнес-процессов утвержден | milestone | 0d | 2018-04-02 11:00 | 2018-04-02 11:00 | 247 | 22.62d | 0d |  |  |
| 249 | 8.2 | **Оптимизация бизнес-процесса 1, 2, 3 … N** |  | 20.25d | 2018-04-02 11:00 | 2018-04-30 13:00 |  | 22.62d |  |  | 97h |
| 250 | 8.2.1 | **Выработка решения по оптимизации** |  | 7.75d | 2018-04-02 11:00 | 2018-04-11 18:00 |  | 22.62d |  |  | 29h |
| 251 | 8.2.1.1 | Косультационаая сессия по оптимизации бизнес-процесса (в группе) |  | 1d | 2018-04-02 11:00 | 2018-04-03 11:00 | 248 | 22.62d | 0d | Эксперт-консультант | 8h |
| 252 | 8.2.1.2 | Моделирование оптимизированного бизнес-процесса |  | 1d | 2018-04-03 11:00 | 2018-04-04 11:00 | 251 | 22.62d | 0d | Эксперт-консультант | 2h |
| 253 | 8.2.1.3 | Создание ТЗ на доработку информационных систем |  | 2d | 2018-04-04 11:00 | 2018-04-06 11:00 | 252 | 22.62d | 0d | Эксперт-консультант | 8h |
| 254 | 8.2.1.4 | Экспорт временных регламентов и инструкций для тестирования процесса |  | 1d | 2018-04-06 11:00 | 2018-04-09 11:00 | 253 | 22.62d | 0d | Эксперт-консультант | 2h |
| 255 | 8.2.1.5 | Консультационная сессия: презентация и защита модели процесса, ТЗ на доработку ИС и временных нормативных документов |  | 0.25d | 2018-04-09 11:00 | 2018-04-09 13:00 | 254 | 22.62d | 0d | Эксперт-консультант | 1h |
| 256 | 8.2.1.6 | Согласование модели процесса, ТЗ на доработку ИС и временных нормативных документов |  | 1d | 2018-04-09 14:00 | 2018-04-10 13:00 | 255 | 22.62d | 0d | Руководитель проекта | 4h |
| 257 | 8.2.1.7 | Выполнение корректировок модели процесса, ТЗ на доработку ИС и временных нормативных документов |  | 1d | 2018-04-10 14:00 | 2018-04-11 13:00 | 256 | 22.62d | 0d | Эксперт-консультант | 2h |
| 258 | 8.2.1.8 | Утверждение модели процесса, ТЗ на доработку ИС и временных нормативных документов |  | 0.5d | 2018-04-11 14:00 | 2018-04-11 18:00 | 257 | 22.62d | 0d | Заказчик | 2h |
| 259 | 8.2.1.9 | Модель оптимизированного процесса, ТЗ на доработку ИС и временные нормативные документы утверждены | milestone | 0d | 2018-04-11 18:00 | 2018-04-11 18:00 | 258 | 22.62d | 0d |  |  |
| 260 | 8.2.2 | **Тестирование оптимизированного бизнес-процесса** |  | 9.75d | 2018-04-12 09:00 | 2018-04-25 16:00 |  | 22.62d |  |  | 57h |
| 261 | 8.2.2.1 | Консультационная сессия: обучение пилотной группы работе по оптимизированному процессу |  | 0.5d | 2018-04-12 09:00 | 2018-04-12 13:00 | 259 | 22.62d | 0d | Эксперт-консультант | 2h |
| 262 | 8.2.2.2 | Тестирование оптимизированного бизнес-процесса |  | 5d | 2018-04-12 14:00 | 2018-04-19 13:00 | 261 | 22.62d | 0d | Функциональный эксперт | 40h |
| 263 | 8.2.2.3 | Анализ результатов тестирования процесса, подготовка отчета |  | 1d | 2018-04-19 14:00 | 2018-04-20 13:00 | 262 | 22.62d | 0d | Эксперт-консультант | 2h |
| 264 | 8.2.2.4 | Консультационная сессия: подведение итогов тестирования оптимизированного процесса |  | 0.25d | 2018-04-20 14:00 | 2018-04-20 16:00 | 263 | 22.62d | 0d | Эксперт-консультант | 1h |
| 265 | 8.2.2.5 | Согласвание оптимизированного процесса к внедрению в постоянную деятельность |  | 1d | 2018-04-20 16:00 | 2018-04-23 16:00 | 264 | 22.62d | 0d | Руководитель проекта | 4h |
| 266 | 8.2.2.6 | Выполнение корректировок оптимизированного бизнес-процесса |  | 1d | 2018-04-23 16:00 | 2018-04-24 16:00 | 265 | 22.62d | 0d | Эксперт-консультант | 4h |
| 267 | 8.2.2.7 | Утверждение оптимизированного процесса к внедрению в постоянную деятельность |  | 1d | 2018-04-24 16:00 | 2018-04-25 16:00 | 266 | 22.62d | 0d | Заказчик | 4h |
| 268 | 8.2.2.8 | Тестирование оптимизированного бизнес-процесса завершено | milestone | 0d | 2018-04-25 16:00 | 2018-04-25 16:00 | 267 | 22.62d | 0d |  |  |

Notes:
- 242: Text1: Видеозапись консультации
- 244: Text1: Видеозапись консультации
- 248: Text1: План по оптимизации бизнес-процессов
- 251: Text1: Видеозапись консультации
- 255: Text1: Видеозапись консультации
- 259: Text1: Модель оптимизированного процесса, ТЗ на доработку ИС и временные нормативные документы
- 261: Text1: Видеозапись консультации
- 263: Text1: Отчет по тестированию оптимзированного процесса
- 264: Text1: Видеозапись консультации
- 268: Text1: Модель оптимизированного процесса, Настроенная ИС, актуальные нормативные документы

| ID | WBS | Task | Type | Duration | Start | Finish | Predecessors | Total slack | Free slack | Resources | Work | Text1 |
| --- | --- | --- | --- | --- | --- | --- | --- | --- | --- | --- | --- | --- |
| 269 | 8.2.3 | **Ввод в действие оптимизированного бизнес-процесса** |  | 2.75d | 2018-04-25 16:00 | 2018-04-30 13:00 |  | 22.62d |  |  | 11h |  |
| 270 | 8.2.3.1 | Замена временных регламентов на постоянные |  | 0.5d | 2018-04-25 16:00 | 2018-04-26 11:00 | 268 | 22.62d | 0d | Заказчик | 2h |  |
| 271 | 8.2.3.2 | Масштабирование доработок информационной системы |  | 2d | 2018-04-26 11:00 | 2018-04-30 11:00 | 270 | 22.62d | 0d | Руководитель проекта | 8h |  |
| 272 | 8.2.3.3 | Консультационная сессия: обучение персонала работе по оптимизированному процессу |  | 0.25d | 2018-04-30 11:00 | 2018-04-30 13:00 | 271 | 22.62d | 0d | Эксперт-консультант | 1h | Видеозапись консультации |
| 273 | 8.2.3.4 | Оптимзированный бизнес-процесс введен в действие | milestone | 0d | 2018-04-30 13:00 | 2018-04-30 13:00 | 272 | 22.62d | 0d |  |  |  |
| 274 | 8.2.4 | Бизнес-процесс оптимзирован | milestone | 0d | 2018-04-30 13:00 | 2018-04-30 13:00 | 273 | 22.62d | 0d |  |  |  |
| 275 | 8.3 | Бизнес-процессы оптимизированы | milestone | 0d | 2018-04-30 13:00 | 2018-04-30 13:00 | 274 | 22.62d |  |  |  |  |
| 276 | 9 | **Автоматизация бизнес-процессов и функций** |  | 23.12d | 2018-03-29 09:00 | 2018-05-01 10:00 |  | 0d |  |  | 97h |  |
| 277 | 9.1 | **Планирование автоматизации** |  | 4.88d | 2018-03-29 09:00 | 2018-04-04 17:00 |  | 0d |  |  | 19h |  |
| 278 | 9.1.1 | Консультационная сессия по автоматизации бизнес-процессов |  | 1.12d | 2018-03-29 09:00 | 2018-03-30 10:00 | 215 | 0d |  | Эксперт-консультант | 2h | Видеозапись консультации |
| 279 | 9.1.2 | Подготовка списка функций к автоматизации и ключевых функциональных требований |  | 1.5d | 2018-03-30 10:00 | 2018-04-02 15:00 | 278 | 0d |  | Эксперт-консультант | 8h |  |
| 280 | 9.1.3 | Консультационная сессия: презентация и защита списка функций к автоматизации и функциональных требований |  | 0.25d | 2018-04-02 15:00 | 2018-04-02 17:00 | 279 | 0d |  | Эксперт-консультант | 1h | Видеозапись консультации |
| 281 | 9.1.4 | Согласование списка функций к автоматизации и функциональных требований |  | 0.5d | 2018-04-02 17:00 | 2018-04-03 12:00 | 280 | 0d |  | Руководитель проекта | 2h |  |
| 282 | 9.1.5 | Выполнение корректировок списка функций к автоматизации и функциональных требований |  | 1d | 2018-04-03 12:00 | 2018-04-04 12:00 | 281 | 0d |  | Эксперт-консультант | 2h |  |
| 283 | 9.1.6 | Утверждение списка функций к автоматизации и функциональных требований |  | 0.5d | 2018-04-04 12:00 | 2018-04-04 17:00 | 282 | 0d |  | Заказчик | 4h |  |
| 284 | 9.1.7 | Список функций к автоматизации и функциональные требования утверждены | milestone | 0d | 2018-04-04 17:00 | 2018-04-04 17:00 | 283 | 0d |  |  |  | Список функций к автоматизации и функциональные требования |
| 285 | 9.2 | **Автоматизация функции 1, 2, 3 … N** |  | 18.25d | 2018-04-04 17:00 | 2018-05-01 10:00 |  | 0d |  |  | 78h |  |
| 286 | 9.2.1 | **Подготовка технического задания** |  | 6.75d | 2018-04-04 17:00 | 2018-04-13 15:00 |  | 0d |  |  | 25h |  |
| 287 | 9.2.1.1 | Формирование технического задания на автоматизацию |  | 3d | 2018-04-04 17:00 | 2018-04-09 17:00 | 284 | 0d |  | Эксперт-консультант | 12h |  |
| 288 | 9.2.1.2 | Консультационная сессия: презентация и защита технического задания |  | 0.25d | 2018-04-09 17:00 | 2018-04-10 10:00 | 287 | 0d |  | Эксперт-консультант | 1h | Видеозапись консультации |
| 289 | 9.2.1.3 | Согласование технического задания на автоматизацию |  | 1d | 2018-04-10 10:00 | 2018-04-11 10:00 | 288 | 0d |  | Руководитель проекта | 4h |  |
| 290 | 9.2.1.4 | Согласование технического задания на автоматизацию |  | 1d | 2018-04-11 10:00 | 2018-04-12 10:00 | 289 | 0d |  | Консультант по ИС | 4h |  |
| 291 | 9.2.1.5 | Выполнение корректировок технического задания на автоматизацию |  | 1d | 2018-04-12 10:00 | 2018-04-13 10:00 | 290 | 0d |  | Эксперт-консультант | 2h |  |
| 292 | 9.2.1.6 | Утверждение технического задания на автоматизацию |  | 0.5d | 2018-04-13 10:00 | 2018-04-13 15:00 | 291 | 0d |  | Заказчик | 2h |  |
| 293 | 9.2.1.7 | Техническое задание утверждено | milestone | 0d | 2018-04-13 15:00 | 2018-04-13 15:00 | 292 | 0d |  |  |  | Техническое задание на автоматизацию |

| ID | WBS | Task | Type | Duration | Start | Finish | Predecessors | Total slack | Free slack | Resources | Work | Text1 |
| --- | --- | --- | --- | --- | --- | --- | --- | --- | --- | --- | --- | --- |
| 294 | 9.2.2 | **Контроль разработки / настройки** |  | 1d | 2018-04-13 15:00 | 2018-04-16 15:00 |  | 0d |  |  | 1h |  |
| 295 | 9.2.2.1 | Консультации с разработчиками / консультантами по ИС в ходе разработки |  | 1d | 2018-04-13 15:00 | 2018-04-16 15:00 | 293 | 0d |  | Эксперт-консультант | 1h |  |
| 296 | 9.2.2.2 | Разработка решения завершена | milestone | 0d | 2018-04-16 15:00 | 2018-04-16 15:00 | 295 | 0d |  |  |  |  |
| 297 | 9.2.3 | **Тестирование решения** |  | 4d | 2018-04-16 15:00 | 2018-04-20 15:00 |  | 0d |  |  | 20h |  |
| 298 | 9.2.3.1 | Подготовка тестовых сценариев |  | 1d | 2018-04-16 15:00 | 2018-04-17 15:00 | 296 | 0d |  | Эксперт-консультант | 4h |  |
| 299 | 9.2.3.2 | Консультационная сессия: презентация и защита тестовых сценариев |  | 0.25d | 2018-04-17 15:00 | 2018-04-17 17:00 | 298 | 0d |  | Эксперт-консультант | 1h |  |
| 300 | 9.2.3.3 | Утверждение тестовых сценариев |  | 0.5d | 2018-04-17 17:00 | 2018-04-18 12:00 | 299 | 0d |  | Консультант по ИС | 2h | Тестовые сценарии |
| 301 | 9.2.3.4 | Выполнение тестирования, подготовка отчета о тестировании |  | 1d | 2018-04-18 12:00 | 2018-04-19 12:00 | 300 | 0d |  | Эксперт-консультант | 4h |  |
| 302 | 9.2.3.5 | Выполнение доработок ИС по итогам тестирования |  | 1d | 2018-04-19 12:00 | 2018-04-20 12:00 | 301 | 0d |  | Консультант по ИС | 8h |  |
| 303 | 9.2.3.6 | Приемка результатов тестирования |  | 0.25d | 2018-04-20 12:00 | 2018-04-20 15:00 | 302 | 0d |  | Руководитель проекта | 1h | Отчет о тестировании |
| 304 | 9.2.3.7 | Тестирование выполнено | milestone | 0d | 2018-04-20 15:00 | 2018-04-20 15:00 | 303 | 0d |  |  |  |  |
| 305 | 9.2.4 | **Ввод решения в эксплуатацию** |  | 6.5d | 2018-04-20 15:00 | 2018-05-01 10:00 |  | 0d |  |  | 32h |  |
| 306 | 9.2.4.1 | Разработка инструкций пользователя (добавление данных в модель процессов) |  | 1d | 2018-04-20 15:00 | 2018-04-23 15:00 | 304 | 0d |  | Эксперт-консультант | 4h |  |
| 307 | 9.2.4.2 | Разработка видеоинструкций |  | 1d | 2018-04-23 15:00 | 2018-04-24 15:00 | 306 | 0d |  | Эксперт-консультант | 4h |  |
| 308 | 9.2.4.3 | Согласование инструкций и видеоинструкций |  | 0.5d | 2018-04-24 15:00 | 2018-04-25 10:00 | 307 | 0d |  | Функциональный эксперт | 2h |  |
| 309 | 9.2.4.4 | Согласование инструкций и видеоинструкций |  | 0.5d | 2018-04-25 10:00 | 2018-04-25 15:00 | 308 | 0d |  | Руководитель проекта | 2h |  |
| 310 | 9.2.4.5 | Утверждение инструкций и видеоинструкций |  | 0.5d | 2018-04-25 15:00 | 2018-04-26 10:00 | 309 | 0d |  | Заказчик | 2h | Инструкции и видеоинструкции для пользователей |
| 311 | 9.2.4.6 | Перенос настроек на рабочую систему |  | 1d | 2018-04-26 10:00 | 2018-04-27 10:00 | 310 | 0d |  | Консультант по ИС | 8h |  |
| 312 | 9.2.4.7 | Ввод или перенос нормативно-справочной информации (НСИ) |  | 1d | 2018-04-27 10:00 | 2018-04-30 10:00 | 311 | 0d |  | Консультант по ИС | 8h |  |
| 313 | 9.2.4.8 | Обучение пользователей |  | 1d | 2018-04-30 10:00 | 2018-05-01 10:00 | 312 | 0d |  | Эксперт-консультант | 2h | Протокол явки на обучение |
| 314 | 9.2.4.9 | Решение введено в эксплуатацию | milestone | 0d | 2018-05-01 10:00 | 2018-05-01 10:00 | 313 | 0d |  |  |  |  |
| 315 | 9.2.5 | Функция автоматизирована | milestone | 0d | 2018-05-01 10:00 | 2018-05-01 10:00 | 314 | 0d |  |  |  |  |
| 316 | 9.3 | Функции и бизнес-процессы автоматизированы | milestone | 0d | 2018-05-01 10:00 | 2018-05-01 10:00 | 315 | 0d |  |  |  |  |
| 317 | 10 | **Регулярная самостоятельная деятельность группы по бизнес-процессам** |  | 22d | 2018-05-01 10:00 | 2018-05-31 10:00 |  | 0d |  |  | 512h |  |
| 318 | 10.1 | **Описание и внедрение новых бизнес-процессов** |  | 8d | 2018-05-01 10:00 | 2018-05-11 10:00 |  | 14d |  |  | 64h |  |
| 319 | 10.1.1 | Моделирование бизнес-процессов по алгоритму (см. задача 6.4.1) |  | 5d | 2018-05-01 10:00 | 2018-05-08 10:00 | 316 | 14d | 0d | Руководитель проекта | 40h |  |
| 320 | 10.1.2 | Формирование нормативных документов и инструкций (см. задача 6.6.2) |  | 2d | 2018-05-08 10:00 | 2018-05-10 10:00 | 319 | 14d | 0d | Руководитель проекта | 16h |  |
| 321 | 10.1.3 | Согласование нормативных документов (см. задачи 6.6.3, 6.6.4, 6.6.5) |  | 1d | 2018-05-10 10:00 | 2018-05-11 10:00 | 320 | 14d |  | Руководитель проекта | 8h |  |

| ID | WBS | Task | Duration | Start | Finish | Predecessors | Total slack | Free slack | Resources | Work |
| --- | --- | --- | --- | --- | --- | --- | --- | --- | --- | --- |
| 322 | 10.2 | **Управление системой показателей деятельности (KPI)** | 10d | 2018-05-01 10:00 | 2018-05-15 10:00 |  | 12d |  |  | 80h |
| 323 | 10.2.1 | Разработка новых показателей | 5d | 2018-05-01 10:00 | 2018-05-08 10:00 | 316 | 12d | 0d | Руководитель проекта | 40h |
| 324 | 10.2.2 | Разработка отчетов для контроля KPI | 5d | 2018-05-08 10:00 | 2018-05-15 10:00 | 323 | 12d |  | Руководитель проекта | 40h |
| 325 | 10.3 | **Сопровождение проектов по автоматизации** | 21d | 2018-05-01 10:00 | 2018-05-30 10:00 |  | 1d |  |  | 168h |
| 326 | 10.3.1 | Написание функциональных требований | 2d | 2018-05-01 10:00 | 2018-05-03 10:00 | 316 | 1d | 0d | Руководитель проекта | 16h |
| 327 | 10.3.2 | Написание технических заданий | 5d | 2018-05-03 10:00 | 2018-05-10 10:00 | 326 | 1d | 0d | Руководитель проекта | 40h |
| 328 | 10.3.3 | Контроль разработки | 10d | 2018-05-10 10:00 | 2018-05-24 10:00 | 327 | 1d | 0d | Руководитель проекта | 80h |
| 329 | 10.3.4 | Организация и проведение тестирования | 2d | 2018-05-24 10:00 | 2018-05-28 10:00 | 328 | 1d | 0d | Руководитель проекта | 16h |
| 330 | 10.3.5 | Разработка инструкций пользователя | 2d | 2018-05-28 10:00 | 2018-05-30 10:00 | 329 | 1d |  | Руководитель проекта | 16h |
| 331 | 10.4 | **Оптимизация бизнес-процессов** | 22d | 2018-05-01 10:00 | 2018-05-31 10:00 |  | 0d |  |  | 200h |
| 332 | 10.4.1 | Планирование оптимизации бизнес-процессов (см. задача 8.1) | 2d | 2018-05-01 10:00 | 2018-05-03 10:00 | 316 | 0d |  | Руководитель проекта | 40h |
| 333 | 10.4.2 | Оптимизация бизнес-процессов по плану (см. задача 8.2) | 20d | 2018-05-03 10:00 | 2018-05-31 10:00 | 332 | 0d |  | Руководитель проекта | 160h |
